# PLANNING & PD&E (EA)

Schedule from MS Project, 2017-09-21 to 2022-09-05.

## Calendars

- Standard: Mon-Fri 08:00-12:00, 13:00-17:00; Sat-Sun off.

## Schedule

| ID | WBS | Task | Type | Duration | Start | Finish | Predecessors | Total slack | Free slack | Constraint | PSM Codes |
| --- | --- | --- | --- | --- | --- | --- | --- | --- | --- | --- | --- |
| 1 | 1 | **PLANNING & PRE-PD&E ACTIVITIES** |  | 409d | 2017-09-21 | 2019-04-16 |  | 0d |  |  |  |
| 2 | 1.1 | SWAT Planning Meeting (May take place 6 months to 5 years before SWAT Kickoff Meeting) | milestone | 1d | 2017-09-21 | 2017-09-21 |  | 0d |  | start no earlier than 2017-09-21 | 746 |
| 3 | 1.2 | **ETDM PLANNING SCREEN** |  | 98d | 2017-10-06 | 2018-02-20 |  | 23d |  |  |  |
| 4 | 1.2.1 | ETDM Planning Screen PED |  | 20d | 2017-10-06 | 2017-11-02 | 2FS+10d | 23d | 0d |  |  |
| 5 | 1.2.2 | ETMD Planning Screen Purpose and Need |  | 20d | 2017-10-06 | 2017-11-02 | 2FS+10d | 23d | 0d |  |  |
| 6 | 1.2.3 | ETDM Planning Screen Start |  | 32d | 2017-11-03 | 2017-12-18 | 4, 5 | 23d | 0d |  |  |
| 7 | 1.2.4 | ETDM Planning Screen Responses |  | 45d | 2017-12-19 | 2018-02-19 | 6 | 23d | 0d |  |  |
| 8 | 1.2.5 | ETDM Planning Summary Screen Report Published |  | 1d | 2018-02-20 | 2018-02-20 | 7 | 23d |  |  |  |
| 9 | 1.3 | SWAT Strategy Meeting (6 months after the SWAT Planning Meeting when the Tentative Work Program has been submitted) |  | 1d | 2018-03-26 | 2018-03-26 | 2FS+131d, 8 | 0d |  |  | 770 |
| 10 | 1.4 | Assign PD&E Project Manager |  | 1d | 2018-03-27 | 2018-03-27 | 9 | 19d |  |  | 704 |
| 11 | 1.5 | SWAT Kickoff Meeting |  | 1d | 2018-09-20 | 2018-09-20 | 18FS+10d | 0d |  |  | 747 |
| 12 | 1.6 | **ETDM PROGRAMMING SCREEN** |  | 97d | 2018-04-24 | 2018-09-05 |  | 0d |  |  |  |
| 13 | 1.6.1 | ETDM Programming Screen PED |  | 20d | 2018-04-24 | 2018-05-21 | 9FS+20d, 10 | 0d |  |  |  |
| 14 | 1.6.2 | ETDM Programming Screen Purpose and Need |  | 20d | 2018-04-24 | 2018-05-21 | 9FS+20d | 0d |  |  |  |
| 15 | 1.6.3 | ETDM Programming Screen Start |  | 32d | 2018-05-22 | 2018-07-04 | 13, 14, 10 | 0d |  |  | 700 |
| 16 | 1.6.4 | Advance Notification |  | 32d | 2018-05-22 | 2018-07-04 | 10, 13, 14 | 0d |  |  | 224 |
| 17 | 1.6.5 | ETDM Programming Screen Responses |  | 44d | 2018-07-05 | 2018-09-04 | 15, 16 | 0d |  |  |  |
| 18 | 1.6.6 | ETDM Programming Final Summary Report Published |  | 1d | 2018-09-05 | 2018-09-05 | 17 | 0d |  |  | 702 |
| 19 | 1.7 | **DEVELOP SCOPE AND SCHEDULE** |  | 20d | 2018-09-21 | 2018-10-18 |  | 0d |  |  |  |
| 20 | 1.7.1 | Initial PD&E Scope (Stage 1) and Schedule Complete |  | 20d | 2018-09-21 | 2018-10-18 | 18, 11 | 0d |  |  | 164 |
| 21 | 1.8 | **PROCUREMENT** |  | 128d | 2018-10-19 | 2019-04-16 |  | 0d |  |  |  |
| 22 | 1.8.1 | PD&E Advertisement |  | 1d | 2018-10-19 | 2018-10-19 | 20 | 0d |  |  | 705 |
| 23 | 1.8.2 | Procurement |  | 120d | 2018-10-22 | 2019-04-05 | 22 | 0d |  |  |  |
| 24 | 1.8.3 | Final PD&E Scope (Stage 3) |  | 5d | 2019-04-08 | 2019-04-12 | 23 | 0d |  |  | 164 |
| 25 | 1.8.4 | PD&E Contract Executed |  | 1d | 2019-04-15 | 2019-04-15 | 24 | 0d |  |  | 239 |
| 26 | 1.8.5 | Notice to Proceed | milestone | 1d | 2019-04-16 | 2019-04-16 | 24, 25 | 0d |  | start no earlier than 2016-04-01 | 234 |

| ID | WBS | Task | Type | Duration | Start | Finish | Predecessors | Total slack | Free slack | PSM Codes |
| --- | --- | --- | --- | --- | --- | --- | --- | --- | --- | --- |
| 27 | 2 | **PD&E STUDY** |  | 885d | 2019-04-16 | 2022-09-05 |  | 0d |  |  |
| 28 | 2.1 | **PROJECT MANAGEMENT** |  | 7d | 2019-04-16 | 2019-04-24 |  | 0d |  |  |
| 29 | 2.1.1 | EA Start |  | 1d | 2019-04-16 | 2019-04-16 | 26FS-1d | 0d |  | 707 |
| 30 | 2.1.2 | Prepare Project Management Plan |  | 5d | 2019-04-17 | 2019-04-23 | 29 | 0d |  |  |
| 31 | 2.1.3 | Prepare QC Plan |  | 5d | 2019-04-17 | 2019-04-23 | 29 | 0d |  |  |
| 32 | 2.1.4 | Project Kickoff Meeting with FDOT |  | 1d | 2019-04-24 | 2019-04-24 | 30, 31 | 0d |  |  |
| 33 | 2.2 | **PUBLIC INVOLVEMENT** |  | 726d | 2019-04-17 | 2022-01-26 |  | 0d |  |  |
| 34 | 2.2.1 | Prepare Public Involvement Plan |  | 20d | 2019-04-17 | 2019-05-14 | 29 | 90d | 31d | 748 |
| 35 | 2.2.2 | Public Involvement Data Collection |  | 45d | 2019-04-25 | 2019-06-26 | 32 | 59d | 0d |  |
| 36 | 2.2.3 | **Prepare for Public Kickoff Meeting** |  | 47d | 2019-06-27 | 2019-08-30 |  | 59d |  | 365 |
| 37 | 2.2.3.1 | Site Review |  | 1d | 2019-06-27 | 2019-06-27 | 34, 35 | 59d | 0d |  |
| 38 | 2.2.3.2 | Newsletter |  | 20d | 2019-06-28 | 2019-07-25 | 37 | 59d | 0d |  |
| 39 | 2.2.3.3 | Prepare Newspaper/ FAR/ FDOT Website Notice |  | 20d | 2019-06-28 | 2019-07-25 | 37 | 59d | 0d |  |
| 40 | 2.2.3.4 | Prepare Elected/Appointed/Property Owner Letters |  | 20d | 2019-06-28 | 2019-07-25 | 37 | 59d | 0d |  |
| 41 | 2.2.3.5 | Presentation/Display Material Review |  | 15d | 2019-07-26 | 2019-08-15 | 40, 38, 39 | 59d | 0d |  |
| 42 | 2.2.3.6 | Public Kickoff Meeting | milestone | 1d | 2019-08-16 | 2019-08-16 | 68, 41 | 59d | 0d | 292 |
| 43 | 2.2.3.7 | Public Comment Period |  | 10d | 2019-08-19 | 2019-08-30 | 42 | 59d | 0d |  |
| 44 | 2.2.4 | **Prepare for Public Information Meeting** |  | 116d | 2020-02-14 | 2020-07-24 |  | 0d |  | 365 |
| 45 | 2.2.4.1 | Site Review |  | 1d | 2020-02-14 | 2020-02-14 | 109FS-60d, 43 | 69d | 0d |  |
| 46 | 2.2.4.2 | Newsletter |  | 20d | 2020-02-17 | 2020-03-13 | 45 | 69d | 0d |  |
| 47 | 2.2.4.3 | Prepare Newspaper/ FAR/ FDOT Website Notice |  | 20d | 2020-02-17 | 2020-03-13 | 45 | 69d | 0d |  |
| 48 | 2.2.4.4 | Prepare Elected/Appointed/Property Owner Letters |  | 20d | 2020-02-17 | 2020-03-13 | 45 | 69d | 0d |  |
| 49 | 2.2.4.5 | Presentation/Display Material Review |  | 15d | 2020-03-16 | 2020-04-03 | 45, 46, 47, 48 | 69d |  |  |
| 50 | 2.2.4.6 | Public Information Meeting | milestone | 1d | 2020-07-10 | 2020-07-10 | 109FS+5d, 49, 88 | 0d |  | 292 |
| 51 | 2.2.4.7 | Public Comment Period |  | 10d | 2020-07-13 | 2020-07-24 | 50 | 0d |  |  |

| ID | WBS | Task | Type | Duration | Start | Finish | Predecessors | Total slack | Free slack | PSM Codes |
| --- | --- | --- | --- | --- | --- | --- | --- | --- | --- | --- |
| 52 | 2.2.5 | **Prepare for Public Hearing** |  | 200d | 2021-04-22 | 2022-01-26 |  | 0d |  | 366 |
| 53 | 2.2.5.1 | Site Review |  | 20d | 2021-04-22 | 2021-05-19 | 51, 152 | 119d | 0d |  |
| 54 | 2.2.5.2 | Newsletter |  | 20d | 2021-05-20 | 2021-06-16 | 53 | 119d |  |  |
| 55 | 2.2.5.3 | Prepare Newspaper/ FAR/ FDOT Website Notice |  | 20d | 2021-11-03 | 2021-11-30 | 53, 157 | 0d |  |  |
| 56 | 2.2.5.4 | Prepare Elected/Appointed/Property Owner Letters |  | 20d | 2021-11-03 | 2021-11-30 | 53, 157 | 0d |  |  |
| 57 | 2.2.5.5 | Presentation/Display Material Review |  | 15d | 2021-12-01 | 2021-12-21 | 53, 54, 55, 56 | 0d |  |  |
| 58 | 2.2.5.6 | Document Available for Public Review |  | 15d | 2021-12-22 | 2022-01-11 | 57, 157, 93 | 0d |  |  |
| 59 | 2.2.5.7 | Public Hearing | milestone | 1d | 2022-01-12 | 2022-01-12 | 58, 57 | 0d |  | 262 |
| 60 | 2.2.5.8 | Public Comment Period |  | 10d | 2022-01-13 | 2022-01-26 | 59 | 0d |  |  |
| 61 | 2.3 | **ENGINEERING ANALYSIS** |  | 552d | 2019-04-17 | 2021-05-27 |  | 6d |  |  |
| 62 | 2.3.1 | **Data Collection** |  | 30d | 2019-04-25 | 2019-06-05 |  | 110d |  |  |
| 63 | 2.3.1.1 | Roadway Data Collection |  | 30d | 2019-04-25 | 2019-06-05 | 32 | 121d | 0d |  |
| 64 | 2.3.1.2 | Drainage Data Collection |  | 30d | 2019-04-25 | 2019-06-05 | 32 | 121d | 0d |  |
| 65 | 2.3.1.3 | Bridge Data Collection |  | 30d | 2019-04-25 | 2019-06-05 | 32 | 121d | 0d |  |
| 66 | 2.3.1.4 | Geotechnical Data Collection |  | 30d | 2019-04-25 | 2019-06-05 | 32 | 121d | 0d |  |
| 67 | 2.3.1.5 | Topographic Survey and ROW Mapping |  | 30d | 2019-04-25 | 2019-06-05 | 32 | 121d | 0d |  |
| 68 | 2.3.1.6 | Prepare Base Map |  | 30d | 2019-04-25 | 2019-06-05 | 32 | 110d | 0d |  |
| 69 | 2.3.2 | **Traffic Analysis** |  | 191d | 2019-04-25 | 2020-01-16 |  | 0d |  |  |
| 70 | 2.3.2.1 | Traffic Methodology Meeting |  | 1d | 2019-04-25 | 2019-04-25 | 32 | 0d |  |  |
| 71 | 2.3.2.2 | Traffic Methodology Memorandum |  | 10d | 2019-04-26 | 2019-05-09 | 70 | 0d |  |  |
| 72 | 2.3.2.3 | Forecasting and Analysis |  | 50d | 2019-05-10 | 2019-07-18 | 71 | 0d |  |  |
| 73 | 2.3.2.4 | Prepare Traffic Projections |  | 40d | 2019-07-19 | 2019-09-12 | 72 | 0d |  |  |
| 74 | 2.3.2.5 | Prepare Capacity Analysis |  | 40d | 2019-09-13 | 2019-11-07 | 73 | 0d |  |  |
| 75 | 2.3.2.6 | Draft Traffic Analysis Report |  | 30d | 2019-11-08 | 2019-12-19 | 74 | 0d |  |  |
| 76 | 2.3.2.7 | District Review - Draft Traffic Analysis Report |  | 15d | 2019-12-20 | 2020-01-09 | 75 | 40d | 0d |  |
| 77 | 2.3.2.8 | Final Traffic Analysis Report |  | 5d | 2020-01-10 | 2020-01-16 | 76 | 40d | 0d | 757 |

| ID | WBS | Task | Duration | Start | Finish | Predecessors | Total slack | Free slack | PSM Codes |
| --- | --- | --- | --- | --- | --- | --- | --- | --- | --- |
| 78 | 2.3.3 | **Interchange Access Request** | 378d | 2019-04-17 | 2020-09-25 |  | 131d |  |  |
| 79 | 2.3.3.1 | Initiate IAR | 1d | 2019-04-17 | 2019-04-17 | 29 | 131d | 0d |  |
| 80 | 2.3.3.2 | Prepare MLOU | 10d | 2019-04-18 | 2019-05-01 | 79 | 131d | 0d |  |
| 81 | 2.3.3.3 | DIRC/SPO Review of MLOU | 15d | 2019-05-02 | 2019-05-22 | 80 | 131d | 0d |  |
| 82 | 2.3.3.4 | FHWA Review of MLOU | 20d | 2019-05-23 | 2019-06-19 | 81 | 131d |  |  |
| 83 | 2.3.3.5 | Develop Alternatives | 40d | 2019-12-20 | 2020-02-13 | 82, 75, 43 | 0d |  |  |
| 84 | 2.3.3.6 | Perform Operational Analysis | 30d | 2020-02-14 | 2020-03-26 | 83 | 0d |  |  |
| 85 | 2.3.3.7 | Prepare Preliminary IAR | 30d | 2020-03-27 | 2020-05-07 | 84 | 0d |  |  |
| 86 | 2.3.3.8 | DIRC/SPO Review of Preliminary IAR | 10d | 2020-05-08 | 2020-05-21 | 85 | 0d |  |  |
| 87 | 2.3.3.9 | Comment Resolution & Update Preliminary IAR | 15d | 2020-05-22 | 2020-06-11 | 86 | 0d |  |  |
| 88 | 2.3.3.10 | FHWA Review of Preliminary IAR | 20d | 2020-06-12 | 2020-07-09 | 87 | 0d |  |  |
| 89 | 2.3.3.11 | Prepare Final IAR | 20d | 2020-07-10 | 2020-08-06 | 88 | 322d | 0d |  |
| 90 | 2.3.3.12 | DIRC/SPO Review of Final IAR | 10d | 2020-08-07 | 2020-08-20 | 89 | 322d | 0d |  |
| 91 | 2.3.3.13 | Comment Resolution & Update Final IAR | 5d | 2020-08-21 | 2020-08-27 | 90 | 322d | 0d |  |
| 92 | 2.3.3.14 | FHWA/SPO Review of IAR | 20d | 2020-08-28 | 2020-09-24 | 91 | 322d | 0d |  |
| 93 | 2.3.3.15 | Safety, Operations & Engineering Approval | 1d | 2020-09-25 | 2020-09-25 | 92 | 322d |  |  |
| 94 | 2.3.4 | **Alternative Analysis** | 516d | 2019-06-06 | 2021-05-27 |  | 0d |  |  |
| 95 | 2.3.4.1 | Roadway Analysis | 40d | 2019-09-02 | 2019-10-25 | 63, 64, 65, 66, 67, 68, 43 | 59d | 0d |  |
| 96 | 2.3.4.2 | Structure Analysis | 40d | 2019-06-06 | 2019-07-31 | 63, 64, 65, 66, 67, 68 | 121d | 62d |  |
| 97 | 2.3.4.3 | Typical Sections Analysis | 40d | 2019-09-02 | 2019-10-25 | 63, 64, 65, 66, 67, 68, 43 | 139d | 99d |  |
| 98 | 2.3.4.4 | Complete Streets/Multi Modal Analysis | 40d | 2019-06-06 | 2019-07-31 | 63, 64, 65, 66, 67 | 201d | 161d |  |
| 99 | 2.3.4.5 | Transit Analysis | 40d | 2020-01-17 | 2020-03-12 | 63, 64, 65, 66, 67, 77, 125 | 40d | 0d |  |
| 100 | 2.3.4.6 | Concept Development | 40d | 2019-10-28 | 2019-12-20 | 63, 64, 65, 66, 67, 68, 95, 96, 43 | 59d | 0d |  |
| 101 | 2.3.4.7 | Access Management Analysis | 40d | 2019-06-06 | 2019-07-31 | 68 | 201d | 161d |  |
| 102 | 2.3.4.8 | Drainage Analysis | 40d | 2019-12-23 | 2020-02-14 | 100 | 59d | 19d |  |
| 103 | 2.3.4.9 | Utility Coordination & Analysis | 40d | 2019-12-23 | 2020-02-14 | 100 | 59d | 19d |  |
| 104 | 2.3.4.10 | Transportation Management Plan | 40d | 2019-12-23 | 2020-02-14 | 100 | 59d | 19d |  |
| 105 | 2.3.4.11 | Railroad Coordination | 40d | 2019-12-23 | 2020-02-14 | 100 | 59d | 19d |  |
| 106 | 2.3.4.12 | Evaluation Matrix (1st Draft) | 5d | 2020-03-13 | 2020-03-19 | 97, 98, 102, 103, 105, 101, 100, 99, 125, 104, 126 | 40d | 0d |  |
| 107 | 2.3.4.13 | Construction Cost Estimates (LRE) | 20d | 2020-03-20 | 2020-04-16 | 106 | 50d | 10d |  |
| 108 | 2.3.4.14 | Right-of-Way Analysis | 20d | 2020-03-20 | 2020-04-16 | 106 | 50d | 10d |  |
| 109 | 2.3.4.15 | Evaluation Matrix (2nd Draft) | 5d | 2020-05-01 | 2020-05-07 | 107, 108, 127, 128, 129, 130, 131, 132 | 40d | 0d |  |
| 110 | 2.3.4.16 | Risk Management | 35d | 2020-05-08 | 2020-06-25 | 109 | 106d |  |  |
| 111 | 2.3.4.17 | Refine Alternatives (based on public input) | 10d | 2020-07-27 | 2020-08-07 | 51 | 0d |  |  |
| 112 | 2.3.4.18 | Prepare 1st Draft Engineering Reports (Drainage, Utility, Roadway Plans, ITS, Lighting, Pavement, Geotech, PER) | 40d | 2020-08-10 | 2020-10-02 | 51, 111, 77, 109 | 0d |  |  |
| 113 | 2.3.4.19 | District Review - 1st Draft Engineering Reports | 20d | 2020-10-05 | 2020-10-30 | 112 | 0d |  |  |
| 114 | 2.3.4.20 | Comment Resolution & Update 1st DRAFT Engineering Reports | 15d | 2020-11-02 | 2020-11-20 | 113 | 0d |  |  |
| 115 | 2.3.4.21 | Value Engineering Study | 5d | 2020-11-23 | 2020-11-27 | 114, 110 | 0d |  |  |
| 116 | 2.3.4.22 | Value Engineering Review | 10d | 2020-12-28 | 2021-01-08 | 115FS+20d | 0d |  | 339 |
| 117 | 2.3.4.23 | Typical Section Selection | 1d | 2021-01-11 | 2021-01-11 | 116 | 20d |  | 759 |
| 118 | 2.3.4.24 | Prepare Design Variations and Exceptions | 20d | 2021-01-11 | 2021-02-05 | 116 | 0d |  |  |
| 119 | 2.3.4.25 | Alternatives Evaluation Complete | 1d | 2021-02-08 | 2021-02-08 | 118 | 0d |  | 712 |
| 120 | 2.3.4.26 | District Review - 2nd Draft Engineering Reports (Drainage, Utility, Roadway Plans, ITS, Lighting, Pavement, Geotech, PER) | 20d | 2021-02-09 | 2021-03-08 | 117, 119, 118 | 0d |  |  |
| 121 | 2.3.4.27 | OEM Engineering Review | 23d | 2021-03-09 | 2021-04-08 | 120 | 0d |  | 772 |
| 122 | 2.3.4.28 | District Prepares Responses | 12d | 2021-04-09 | 2021-04-26 | 121 | 0d |  | 773 |
| 123 | 2.3.4.29 | OEM/District Comment Resolution | 23d | 2021-04-27 | 2021-05-27 | 122 | 0d |  | 774 |

| ID | WBS | Task | Duration | Start | Finish | Predecessors | Total slack | Free slack | PSM Codes |
| --- | --- | --- | --- | --- | --- | --- | --- | --- | --- |
| 124 | 2.4 | **ENVIRONMENTAL ANALYSIS** | 470d | 2019-04-25 | 2021-02-10 |  | 26d |  |  |
| 125 | 2.4.1 | Environmental GIS Data Collection | 20d | 2019-04-25 | 2019-05-22 | 32 | 211d | 0d |  |
| 126 | 2.4.2 | Environmental GIS Desktop Analysis | 40d | 2019-05-23 | 2019-07-17 | 125 | 211d | 171d |  |
| 127 | 2.4.3 | Data Collection & CRAS | 30d | 2020-03-20 | 2020-04-30 | 106 | 40d | 0d |  |
| 128 | 2.4.4 | Data Collection & Noise Analysis | 30d | 2020-03-20 | 2020-04-30 | 106, 77 | 40d | 0d |  |
| 129 | 2.4.5 | Data Collection & Contamination Screen Evaluation | 30d | 2020-03-20 | 2020-04-30 | 106 | 40d | 0d |  |
| 130 | 2.4.6 | Wetland Delineation and Evaluation | 30d | 2020-03-20 | 2020-04-30 | 106 | 40d | 0d |  |
| 131 | 2.4.7 | Data Collection & Wildlife Survey | 30d | 2020-03-20 | 2020-04-30 | 106 | 40d | 0d |  |
| 132 | 2.4.8 | Essential Fish Habitat Evaluation | 30d | 2020-03-20 | 2020-04-30 | 106 | 40d | 0d |  |
| 133 | 2.4.9 | Determination of Section 4(f) | 30d | 2020-03-20 | 2020-04-30 | 106 | 112d | 0d |  |
| 134 | 2.4.10 | Prepare 1st Draft NRE Report | 25d | 2020-05-01 | 2020-06-04 | 130, 131, 132 | 112d | 0d |  |
| 135 | 2.4.11 | Prepare 1st Draft CRAS | 25d | 2020-05-01 | 2020-06-04 | 127 | 112d | 0d |  |
| 136 | 2.4.12 | Prepare 1st Draft CSER | 25d | 2020-05-01 | 2020-06-04 | 129 | 112d | 0d |  |
| 137 | 2.4.13 | Prepare 1st Draft NSR | 25d | 2020-05-01 | 2020-06-04 | 128 | 112d | 0d |  |
| 138 | 2.4.14 | Prepare Draft Section 4(f) | 25d | 2020-05-01 | 2020-06-04 | 133 | 112d | 0d |  |
| 139 | 2.4.15 | District Review 1st Draft Environmental Reports (NRE, CSER, CRAS, Noise, Section 4(f)) | 20d | 2020-06-05 | 2020-07-02 | 134, 135, 136, 137, 138 | 112d | 0d |  |
| 140 | 2.4.16 | Comment Resolution & Update Draft Environmental Reports | 15d | 2020-07-03 | 2020-07-23 | 139 | 112d | 0d |  |
| 141 | 2.4.17 | OEM Review NRE | 25d | 2020-07-24 | 2020-08-27 | 139, 140 | 112d | 0d |  |
| 142 | 2.4.18 | Finalize CRAS | 10d | 2020-07-24 | 2020-08-06 | 140 | 159d | 0d | 333 |
| 143 | 2.4.19 | Finalize NRE Report | 10d | 2020-08-28 | 2020-09-10 | 140, 141 | 112d | 86d | 761 |
| 144 | 2.4.20 | Section 106 Effects Complete | 1d | 2020-08-07 | 2020-08-07 | 142 | 159d | 133d | 762 |
| 145 | 2.4.21 | Submit NRE to USFWS, NMFS, USACE, and FWS | 1d | 2021-01-11 | 2021-01-11 | 143, 116 | 26d | 0d |  |
| 146 | 2.4.22 | Informal USFWS Consultation Complete | 22d | 2021-01-12 | 2021-02-10 | 145 | 26d | 0d | 752 |
| 147 | 2.4.23 | Informal NMFS Consultation Complete | 22d | 2021-01-12 | 2021-02-10 | 145 | 26d | 0d | 763 |
| 148 | 2.4.24 | Prepare Conceptual Stage Relocation Plan | 20d | 2021-01-11 | 2021-02-05 | 116 | 29d | 3d |  |

| ID | WBS | Task | Type | Duration | Start | Finish | Predecessors | Total slack | Free slack | PSM Codes |
| --- | --- | --- | --- | --- | --- | --- | --- | --- | --- | --- |
| 149 | 2.5 | **FINAL ENGINEERING & EA DOCUMENTATION** |  | 884d | 2019-04-17 | 2022-09-05 |  | 0d |  |  |
| 150 | 2.5.1 | Prepare Draft EA for Public Availability |  | 30d | 2021-02-11 | 2021-03-24 | 116, 18, 144, 146, 147, 148 | 26d | 0d |  |
| 151 | 2.5.2 | Planning Consistency Complete |  | 1d | 2019-04-17 | 2019-04-17 | 29 | 531d | 505d | 710 |
| 152 | 2.5.3 | District QC Draft Environment Document |  | 20d | 2021-03-25 | 2021-04-21 | 150, 151 | 26d | 0d | 713 |
| 153 | 2.5.4 | EA to OEM Initial Review |  | 23d | 2021-05-28 | 2021-06-29 | 152, 123 | 0d |  | 718 |
| 154 | 2.5.5 | EA to Cooperating Agency Initial Review |  | 23d | 2021-05-28 | 2021-06-29 | 152, 123 | 0d |  | 716 |
| 155 | 2.5.6 | District Prepares Responses |  | 12d | 2021-06-30 | 2021-07-15 | 153, 154 | 0d |  | 773 |
| 156 | 2.5.7 | OEM/District Comment Resolution |  | 23d | 2021-07-16 | 2021-08-17 | 155 | 0d |  | 774 |
| 157 | 2.5.8 | EA OEM Approval Final Review, Legal Sufficiency Review for Section 4(f) and Approval |  | 55d | 2021-08-18 | 2021-11-02 | 156 | 0d |  | 719 |
| 158 | 2.5.9 | Finalize Engineering & Environmental Reports |  | 10d | 2022-01-27 | 2022-02-09 | 60 | 50d |  |  |
| 159 | 2.5.10 | Finalize Section 4(f) |  | 60d | 2022-01-27 | 2022-04-20 | 60 | 0d |  | 751 |
| 160 | 2.5.11 | Finalize PD&E NSR |  | 5d | 2022-01-27 | 2022-02-02 | 60 | 55d |  | 335 |
| 161 | 2.5.12 | Finalize PER |  | 5d | 2022-01-27 | 2022-02-02 | 60 | 55d |  | 760 |
| 162 | 2.5.13 | FONSI to OEM Initial Review |  | 23d | 2022-04-21 | 2022-05-23 | 60, 158, 161, 159, 160 | 0d |  | 731 |
| 163 | 2.5.14 | FONSI to Cooperating Agencies Initial Review |  | 23d | 2022-04-21 | 2022-05-23 | 60, 158, 159, 160, 161 | 0d |  | 717 |
| 164 | 2.5.15 | District Prepares Responses |  | 12d | 2022-05-24 | 2022-06-08 | 162, 163 | 0d |  | 773 |
| 165 | 2.5.16 | OEM/District Comment Resolution |  | 23d | 2022-06-09 | 2022-07-11 | 164 | 0d |  | 774 |
| 166 | 2.5.17 | FONSI OEM Approval Final Review |  | 32d | 2022-07-12 | 2022-08-24 | 165 | 0d |  | 732 |
| 167 | 2.5.18 | Location Design Concept Acceptance |  | 1d | 2022-08-25 | 2022-08-25 | 166 | 0d |  | 263 |
| 168 | 2.5.19 | EA and FONSI uploaded to ETDM |  | 1d | 2022-08-26 | 2022-08-26 | 166, 167 | 5d |  |  |
| 169 | 2.5.20 | Local Design Concept Acceptance Public Notice | milestone | 1d | 2022-08-26 | 2022-08-26 | 167 | 0d |  | 736 |
| 170 | 2.5.21 | Interchange Access Request Approval |  | 5d | 2022-08-29 | 2022-09-02 | 169, 93 | 0d |  | 765 |
| 171 | 2.5.22 | Pass the Torch Meeting |  | 1d | 2022-09-05 | 2022-09-05 | 169, 168, 170 | 0d |  |  |
