# PLANNING & PD&E (EIS)

Schedule from MS Project, 2017-09-21 to 2023-04-03.

## Calendars

- Standard: Mon-Fri 08:00-12:00, 13:00-17:00; Sat-Sun off.

## Schedule

| ID | WBS | Task | Type | Duration | Start | Finish | Predecessors | Total slack | Free slack | Constraint | PSM Codes |
| --- | --- | --- | --- | --- | --- | --- | --- | --- | --- | --- | --- |
| 1 | 1 | **PLANNING & PRE-PD&E ACTIVITIES** |  | 409d | 2017-09-21 | 2019-04-16 |  | 0d |  |  |  |
| 2 | 1.1 | SWAT Planning Meeting (May take place 6 months to 5 years before SWAT Kickoff Meeting) | milestone | 1d | 2017-09-21 | 2017-09-21 |  | 0d |  | start no earlier than 2017-09-21 | 746 |
| 3 | 1.2 | **ETDM PLANNING SCREEN** |  | 98d | 2017-10-06 | 2018-02-20 |  | 23d |  |  |  |
| 4 | 1.2.1 | ETDM Planning Screen PED |  | 20d | 2017-10-06 | 2017-11-02 | 2FS+10d | 23d | 0d |  |  |
| 5 | 1.2.2 | ETMD Planning Screen Purpose and Need |  | 20d | 2017-10-06 | 2017-11-02 | 2FS+10d | 23d | 0d |  |  |
| 6 | 1.2.3 | ETDM Planning Screen Start |  | 32d | 2017-11-03 | 2017-12-18 | 4, 5 | 23d | 0d |  |  |
| 7 | 1.2.4 | ETDM Planning Screen Responses |  | 45d | 2017-12-19 | 2018-02-19 | 6 | 23d | 0d |  |  |
| 8 | 1.2.5 | ETDM Planning Summary Screen Report Published |  | 1d | 2018-02-20 | 2018-02-20 | 7 | 23d |  |  |  |
| 9 | 1.3 | SWAT Strategy Meeting (6 months after the SWAT Planning Meeting when the Tentative Work Program has been submitted) |  | 1d | 2018-03-26 | 2018-03-26 | 2FS+131d, 8 | 0d |  |  | 770 |
| 10 | 1.4 | Assign PD&E Project Manager |  | 1d | 2018-03-27 | 2018-03-27 | 9 | 19d |  |  | 704 |
| 11 | 1.5 | SWAT Kickoff Meeting |  | 1d | 2018-09-20 | 2018-09-20 | 18FS+10d | 0d |  |  | 747 |
| 12 | 1.6 | **ETDM PROGRAMMING SCREEN** |  | 97d | 2018-04-24 | 2018-09-05 |  | 0d |  |  |  |
| 13 | 1.6.1 | ETDM Programming Screen PED |  | 20d | 2018-04-24 | 2018-05-21 | 9FS+20d, 10 | 0d |  |  |  |
| 14 | 1.6.2 | ETDM Programming Screen Purpose and Need |  | 20d | 2018-04-24 | 2018-05-21 | 9FS+20d | 0d |  |  |  |
| 15 | 1.6.3 | ETDM/ETAT Programming Screen Start |  | 32d | 2018-05-22 | 2018-07-04 | 10, 13, 14 | 0d |  |  | 700 |
| 16 | 1.6.4 | Advance Notification |  | 32d | 2018-05-22 | 2018-07-04 | 10, 13, 14 | 0d |  |  | 224 |
| 17 | 1.6.5 | ETDM Programming Screen Responses |  | 44d | 2018-07-05 | 2018-09-04 | 15, 16 | 0d |  |  |  |
| 18 | 1.6.6 | ETDM Programming Final Summary Report Published |  | 1d | 2018-09-05 | 2018-09-05 | 17 | 0d |  |  | 702 |
| 19 | 1.7 | **DEVELOP SCOPE AND SCHEDULE** |  | 20d | 2018-09-21 | 2018-10-18 |  | 0d |  |  |  |
| 20 | 1.7.1 | Initial PD&E Scope (Stage 1) and Schedule Complete |  | 20d | 2018-09-21 | 2018-10-18 | 11, 18 | 0d |  |  | 164 |
| 21 | 1.8 | **PROCUREMENT** |  | 128d | 2018-10-19 | 2019-04-16 |  | 0d |  |  |  |
| 22 | 1.8.1 | PD&E Advertisement |  | 1d | 2018-10-19 | 2018-10-19 | 20 | 0d |  |  | 705 |
| 23 | 1.8.2 | Procurement |  | 120d | 2018-10-22 | 2019-04-05 | 22 | 0d |  |  |  |
| 24 | 1.8.3 | Final PD&E Scope (Stage 3) |  | 5d | 2019-04-08 | 2019-04-12 | 23 | 0d |  |  | 164 |
| 25 | 1.8.4 | PD&E Contract Executed |  | 1d | 2019-04-15 | 2019-04-15 | 24 | 0d |  |  | 239 |
| 26 | 1.8.5 | Notice to Proceed | milestone | 1d | 2019-04-16 | 2019-04-16 | 24, 25 | 0d |  | start no earlier than 2016-04-01 | 234 |

| ID | WBS | Task | Type | Duration | Start | Finish | Predecessors | Total slack | Free slack | PSM Codes |
| --- | --- | --- | --- | --- | --- | --- | --- | --- | --- | --- |
| 27 | 2 | **PD&E STUDY** |  | 1034d | 2019-04-17 | 2023-04-03 |  | 0d |  |  |
| 28 | 2.1 | **PROJECT MANAGEMENT** |  | 55d | 2019-04-17 | 2019-07-02 |  | 0d |  |  |
| 29 | 2.1.1 | Prepare Project Management Plan |  | 5d | 2019-04-17 | 2019-04-23 | 26 | 0d |  |  |
| 30 | 2.1.2 | Prepare QC Plan |  | 5d | 2019-04-17 | 2019-04-23 | 26 | 0d |  |  |
| 31 | 2.1.3 | Project Kickoff Meeting with FDOT |  | 1d | 2019-04-24 | 2019-04-24 | 29, 30 | 0d |  |  |
| 32 | 2.1.4 | Prepare Draft NOI |  | 5d | 2019-04-25 | 2019-05-01 | 31 | 121d | 0d |  |
| 33 | 2.1.5 | District Review of NOI |  | 5d | 2019-05-02 | 2019-05-08 | 32 | 121d | 0d |  |
| 34 | 2.1.6 | OEM NOI Approval Final Review |  | 15d | 2019-05-09 | 2019-05-29 | 33 | 121d | 0d | 723 |
| 35 | 2.1.7 | NOI - EIS Start |  | 17d | 2019-06-10 | 2019-07-02 | 34FS+7d | 121d | 0d | 708 |
| 36 | 2.2 | **PUBLIC INVOLVEMENT** |  | 861d | 2019-04-17 | 2022-08-03 |  | 0d |  |  |
| 37 | 2.2.1 | Prepare Public Involvement Plan |  | 20d | 2019-04-17 | 2019-05-14 | 26 | 155d | 31d | 748 |
| 38 | 2.2.2 | Public Involvement Data Collection |  | 45d | 2019-04-25 | 2019-06-26 | 31 | 124d | 0d |  |
| 39 | 2.2.3 | EIS Scoping Meeting |  | 1d | 2019-07-03 | 2019-07-03 | 37, 38, 35 | 136d | 0d | 741 |
| 40 | 2.2.4 | **Prepare for Public Kickoff Meeting** |  | 47d | 2019-06-27 | 2019-08-30 |  | 124d |  | 365 |
| 41 | 2.2.4.1 | Site Review |  | 1d | 2019-06-27 | 2019-06-27 | 37, 38 | 124d | 0d |  |
| 42 | 2.2.4.2 | Newsletter |  | 20d | 2019-06-28 | 2019-07-25 | 41 | 124d | 0d |  |
| 43 | 2.2.4.3 | Prepare Newspaper/ FAR/ FDOT Website Notice |  | 20d | 2019-06-28 | 2019-07-25 | 41 | 124d | 0d |  |
| 44 | 2.2.4.4 | Prepare Elected/Appointed/Property Owner Letters |  | 20d | 2019-06-28 | 2019-07-25 | 41 | 124d | 0d |  |
| 45 | 2.2.4.5 | Presentation/Display Material Review |  | 15d | 2019-07-26 | 2019-08-15 | 42, 43, 44 | 124d | 0d |  |
| 46 | 2.2.4.6 | Public Kickoff Meeting | milestone | 1d | 2019-08-16 | 2019-08-16 | 45, 72 | 124d | 0d | 292 |
| 47 | 2.2.4.7 | Public Comment Period |  | 10d | 2019-08-19 | 2019-08-30 | 46 | 124d | 0d |  |
| 48 | 2.2.5 | **Prepare for Public Information Meeting** |  | 76d | 2020-09-04 | 2020-12-18 |  | 0d |  | 365 |
| 49 | 2.2.5.1 | Site Review |  | 1d | 2020-09-04 | 2020-09-04 | 113FS-60d, 47 | 29d | 0d |  |
| 50 | 2.2.5.2 | Newsletter |  | 20d | 2020-09-07 | 2020-10-02 | 49 | 29d | 0d |  |
| 51 | 2.2.5.3 | Prepare Newspaper/ FAR/ FDOT Website Notice |  | 20d | 2020-09-07 | 2020-10-02 | 49 | 29d | 0d |  |
| 52 | 2.2.5.4 | Prepare Elected/Appointed/Property Owner Letters |  | 20d | 2020-09-07 | 2020-10-02 | 49 | 29d | 0d |  |
| 53 | 2.2.5.5 | Presentation/Display Material Review |  | 15d | 2020-10-05 | 2020-10-23 | 49, 50, 51, 52 | 29d |  |  |
| 54 | 2.2.5.6 | Public Information Meeting | milestone | 1d | 2020-12-04 | 2020-12-04 | 113FS+5d, 53, 92 | 0d |  | 292 |
| 55 | 2.2.5.7 | Public Comment Period |  | 10d | 2020-12-07 | 2020-12-18 | 54 | 0d |  |  |

| ID | WBS | Task | Type | Duration | Start | Finish | Predecessors | Total slack | Free slack | PSM Codes |
| --- | --- | --- | --- | --- | --- | --- | --- | --- | --- | --- |
| 56 | 2.2.6 | **Prepare for Public Hearing** |  | 81d | 2022-04-13 | 2022-08-03 |  | 0d |  | 366 |
| 57 | 2.2.6.1 | Site Review |  | 20d | 2022-04-13 | 2022-05-10 | 160 | 0d |  |  |
| 58 | 2.2.6.2 | Newsletter |  | 20d | 2022-05-11 | 2022-06-07 | 57 | 0d |  |  |
| 59 | 2.2.6.3 | Prepare Newspaper/ FAR/ FDOT Website Notice |  | 20d | 2022-05-11 | 2022-06-07 | 57 | 0d |  |  |
| 60 | 2.2.6.4 | Prepare Elected/Appointed/Property Owner Letters |  | 20d | 2022-05-11 | 2022-06-07 | 57 | 0d |  |  |
| 61 | 2.2.6.5 | Presentation/Display Material Review |  | 15d | 2022-06-08 | 2022-06-28 | 57, 58, 59, 60 | 0d |  |  |
| 62 | 2.2.6.6 | Document Available for Public Review |  | 15d | 2022-06-29 | 2022-07-19 | 61, 97, 127 | 0d |  |  |
| 63 | 2.2.6.7 | Public Hearing | milestone | 1d | 2022-07-20 | 2022-07-20 | 61, 62 | 0d |  | 262 |
| 64 | 2.2.6.8 | Public Comment Period |  | 10d | 2022-07-21 | 2022-08-03 | 63 | 0d |  |  |
| 65 | 2.3 | **ENGINEERING ANALYSIS** |  | 672d | 2019-04-25 | 2021-11-19 |  | 0d |  |  |
| 66 | 2.3.1 | **Data Collection** |  | 110d | 2019-04-25 | 2019-09-25 |  | 136d |  |  |
| 67 | 2.3.1.1 | Roadway Data Collection |  | 60d | 2019-07-04 | 2019-09-25 | 39, 31 | 136d | 0d |  |
| 68 | 2.3.1.2 | Drainage Data Collection |  | 60d | 2019-07-04 | 2019-09-25 | 39, 31 | 136d | 0d |  |
| 69 | 2.3.1.3 | Bridge Data Collection |  | 60d | 2019-07-04 | 2019-09-25 | 39, 31 | 136d | 0d |  |
| 70 | 2.3.1.4 | Geotechnical Data Collection |  | 60d | 2019-04-25 | 2019-07-17 | 31 | 186d | 50d |  |
| 71 | 2.3.1.5 | Topographic Survey and ROW Mapping |  | 60d | 2019-04-25 | 2019-07-17 | 31 | 186d | 50d |  |
| 72 | 2.3.1.6 | Prepare Base Map |  | 60d | 2019-04-25 | 2019-07-17 | 31 | 145d | 21d |  |
| 73 | 2.3.2 | **Traffic Analysis** |  | 246d | 2019-04-25 | 2020-04-02 |  | 0d |  |  |
| 74 | 2.3.2.1 | Traffic Methodology Meeting |  | 1d | 2019-04-25 | 2019-04-25 | 31 | 0d |  |  |
| 75 | 2.3.2.2 | Traffic Methodology Memorandum |  | 10d | 2019-04-26 | 2019-05-09 | 74 | 0d |  |  |
| 76 | 2.3.2.3 | Forecasting and Analysis |  | 60d | 2019-05-10 | 2019-08-01 | 75 | 0d |  |  |
| 77 | 2.3.2.4 | Prepare Traffic Projections |  | 50d | 2019-08-02 | 2019-10-10 | 76 | 0d |  |  |
| 78 | 2.3.2.5 | Prepare Capacity Analysis |  | 50d | 2019-10-11 | 2019-12-19 | 77 | 0d |  |  |
| 79 | 2.3.2.6 | Draft Traffic Analysis Report |  | 50d | 2019-12-20 | 2020-02-27 | 78 | 0d |  |  |
| 80 | 2.3.2.7 | District Review - Draft Traffic Analysis Report |  | 20d | 2020-02-28 | 2020-03-26 | 79 | 0d |  |  |
| 81 | 2.3.2.8 | Final Traffic Analysis Report |  | 5d | 2020-03-27 | 2020-04-02 | 80 | 0d |  | 757 |

| ID | WBS | Task | Duration | Start | Finish | Predecessors | Total slack | Free slack | PSM Codes |
| --- | --- | --- | --- | --- | --- | --- | --- | --- | --- |
| 82 | 2.3.3 | **Interchange Access Request** | 327d | 2019-07-03 | 2020-10-01 |  | 121d |  |  |
| 83 | 2.3.3.1 | Initiate IAR | 1d | 2019-07-03 | 2019-07-03 | 35 | 121d | 0d |  |
| 84 | 2.3.3.2 | Prepare MLOU | 10d | 2019-07-04 | 2019-07-17 | 83 | 121d | 0d |  |
| 85 | 2.3.3.3 | DIRC/SPO Review of MLOU | 15d | 2019-07-18 | 2019-08-07 | 84 | 121d | 0d |  |
| 86 | 2.3.3.4 | FHWA Review of MLOU | 20d | 2019-08-08 | 2019-09-04 | 85 | 121d | 0d |  |
| 87 | 2.3.3.5 | Develop Alternatives | 60d | 2019-09-05 | 2019-11-27 | 47, 86 | 121d | 0d |  |
| 88 | 2.3.3.6 | Perform Operational Analysis | 50d | 2019-11-28 | 2020-02-05 | 87 | 121d | 0d |  |
| 89 | 2.3.3.7 | Prepare Preliminary IAR | 50d | 2020-02-06 | 2020-04-15 | 88 | 121d | 0d |  |
| 90 | 2.3.3.8 | DIRC/SPO Review of Preliminary IAR | 10d | 2020-04-16 | 2020-04-29 | 89 | 121d | 0d |  |
| 91 | 2.3.3.9 | Comment Resolution & Update Preliminary IAR | 15d | 2020-04-30 | 2020-05-20 | 90 | 121d | 0d |  |
| 92 | 2.3.3.10 | FHWA Review of Preliminary IAR | 20d | 2020-05-21 | 2020-06-17 | 91 | 121d | 0d |  |
| 93 | 2.3.3.11 | Prepare Final IAR | 40d | 2020-06-18 | 2020-08-12 | 92 | 453d | 0d |  |
| 94 | 2.3.3.12 | DIRC/SPO Review of Final IAR | 10d | 2020-08-13 | 2020-08-26 | 93 | 453d | 0d |  |
| 95 | 2.3.3.13 | Comment Resolution & Update Final IAR | 5d | 2020-08-27 | 2020-09-02 | 94 | 453d | 0d |  |
| 96 | 2.3.3.14 | FHWA/SPO Review of IAR | 20d | 2020-09-03 | 2020-09-30 | 95 | 453d | 0d |  |
| 97 | 2.3.3.15 | Safety, Operations and Engineering Approval | 1d | 2020-10-01 | 2020-10-01 | 96 | 453d |  |  |
| 98 | 2.3.4 | **Alternative Analysis** | 580d | 2019-09-02 | 2021-11-19 |  | 154d |  |  |
| 99 | 2.3.4.1 | Roadway Analysis | 60d | 2019-09-02 | 2019-11-22 | 47 | 214d |  |  |
| 100 | 2.3.4.2 | Structure Analysis | 60d | 2019-09-26 | 2019-12-18 | 67, 68, 69, 70, 71 | 196d |  |  |
| 101 | 2.3.4.3 | Typical Sections Analysis | 60d | 2019-09-26 | 2019-12-18 | 47, 67, 68, 69, 70, 71 | 196d |  |  |
| 102 | 2.3.4.4 | Complete Streets/Multi Modal Analysis | 60d | 2019-09-26 | 2019-12-18 | 67, 68, 69, 70, 71 | 196d |  |  |
| 103 | 2.3.4.5 | Transit Analysis | 60d | 2020-04-03 | 2020-06-25 | 67, 68, 69, 70, 129, 81 | 60d | 0d |  |
| 104 | 2.3.4.6 | Concept Development | 60d | 2020-04-03 | 2020-06-25 | 47, 67, 68, 69, 70, 71, 72, 81 | 0d |  |  |
| 105 | 2.3.4.7 | Access Management Analysis | 60d | 2020-04-03 | 2020-06-25 | 81 | 60d |  |  |
| 106 | 2.3.4.8 | Drainage Analysis | 60d | 2020-06-26 | 2020-09-17 | 104 | 0d |  |  |
| 107 | 2.3.4.9 | Utility Coordination & Analysis | 60d | 2020-06-26 | 2020-09-17 | 104 | 0d |  |  |
| 108 | 2.3.4.10 | Transportation Management Plan | 60d | 2020-06-26 | 2020-09-17 | 104 | 0d |  |  |
| 109 | 2.3.4.11 | Railroad Coordination | 60d | 2020-06-26 | 2020-09-17 | 104 | 0d |  |  |
| 110 | 2.3.4.12 | Evaluation Matrix (1st Draft) | 5d | 2020-09-18 | 2020-09-24 | 99, 100, 101, 102, 105, 106, 107, 108, 109, 104, 103, 129, 130 | 0d |  |  |
| 111 | 2.3.4.13 | Construction Cost Estimates (LRE) | 30d | 2020-09-25 | 2020-11-05 | 110 | 10d |  |  |
| 112 | 2.3.4.14 | Right-of-Way Analysis | 30d | 2020-09-25 | 2020-11-05 | 110 | 10d |  |  |
| 113 | 2.3.4.15 | Evaluation Matrix (2nd Draft) | 5d | 2020-11-20 | 2020-11-26 | 111, 112, 131, 132, 133, 134, 135, 136 | 0d |  |  |
| 114 | 2.3.4.16 | Risk Management | 50d | 2020-06-26 | 2020-09-03 | 103 | 181d |  |  |
| 115 | 2.3.4.17 | Refine Alternatives (based on public input) | 20d | 2020-12-21 | 2021-01-15 | 55 | 0d |  |  |
| 116 | 2.3.4.18 | Prepare 1st Draft Engineering Reports (Drainage, Utility, Roadway Plans, ITS, Lighting, Pavement, Geotech, PER) | 50d | 2021-01-18 | 2021-03-26 | 55, 115, 81 | 0d |  |  |
| 117 | 2.3.4.19 | District Review - 1st Draft Engineering Reports | 20d | 2021-03-29 | 2021-04-23 | 116 | 0d |  |  |
| 118 | 2.3.4.20 | Update 1st Draft Engineering Reports | 15d | 2021-04-26 | 2021-05-14 | 117 | 0d |  |  |
| 119 | 2.3.4.21 | Value Engineering Study | 5d | 2021-05-17 | 2021-05-21 | 114, 118 | 0d |  |  |
| 120 | 2.3.4.22 | Value Engineering Review | 10d | 2021-06-21 | 2021-07-02 | 119FS+20d | 0d |  | 339 |
| 121 | 2.3.4.23 | Typical Section Selection | 1d | 2021-07-05 | 2021-07-05 | 120 | 20d |  | 759 |
| 122 | 2.3.4.24 | Prepare Design Variations and Exceptions | 20d | 2021-07-05 | 2021-07-30 | 120 | 0d |  |  |
| 123 | 2.3.4.25 | Alternatives Evaluation Complete | 1d | 2021-08-02 | 2021-08-02 | 122 | 0d |  | 712 |
| 124 | 2.3.4.26 | District Review - 2nd Draft Engineering Reports (Drainage, Utility, Roadway Plans, ITS, Lighting, Pavement, Geotech, PER) | 20d | 2021-08-03 | 2021-08-30 | 121, 123 | 0d |  |  |
| 125 | 2.3.4.27 | OEM Engineering Review | 23d | 2021-08-31 | 2021-09-30 | 124 | 157d | 0d | 772 |
| 126 | 2.3.4.28 | District Prepares Responses | 12d | 2021-10-01 | 2021-10-18 | 125 | 157d | 0d | 773 |
| 127 | 2.3.4.29 | OEM/District Comments Resolution | 24d | 2021-10-19 | 2021-11-19 | 126 | 157d |  | 774 |

| ID | WBS | Task | Duration | Start | Finish | Predecessors | Total slack | Free slack | PSM Codes |
| --- | --- | --- | --- | --- | --- | --- | --- | --- | --- |
| 128 | 2.4 | **ENVIRONMENTAL ANALYSIS** | 595d | 2019-04-25 | 2021-08-04 |  | 18d |  |  |
| 129 | 2.4.1 | Environmental GIS Data Collection | 30d | 2019-04-25 | 2019-06-05 | 31 | 276d | 0d |  |
| 130 | 2.4.2 | Environmental GIS Desktop Analysis | 60d | 2019-06-06 | 2019-08-28 | 129 | 276d |  |  |
| 131 | 2.4.3 | Data Collection & CRAS | 40d | 2020-09-25 | 2020-11-19 | 39, 110 | 0d |  |  |
| 132 | 2.4.4 | Data Collection & Noise Analysis | 40d | 2020-09-25 | 2020-11-19 | 39, 110, 81 | 0d |  |  |
| 133 | 2.4.5 | Data Collection & Contamination Screen Evaluation | 40d | 2020-09-25 | 2020-11-19 | 39, 110 | 0d |  |  |
| 134 | 2.4.6 | Wetland Delineation and Evaluation | 40d | 2020-09-25 | 2020-11-19 | 39, 110 | 0d |  |  |
| 135 | 2.4.7 | Data Collection & Wildlife Survey | 40d | 2020-09-25 | 2020-11-19 | 39, 110 | 0d |  |  |
| 136 | 2.4.8 | Essential Fish Habitat Evaluation | 40d | 2020-09-25 | 2020-11-19 | 39, 110 | 0d |  |  |
| 137 | 2.4.9 | Determination of Section 4(f) | 40d | 2020-09-25 | 2020-11-19 | 110 | 79d | 0d |  |
| 138 | 2.4.10 | Prepare 1st Draft NRE Report | 30d | 2020-11-20 | 2020-12-31 | 134, 135, 136 | 79d | 0d |  |
| 139 | 2.4.11 | Prepare 1st Draft CRAS | 30d | 2020-11-20 | 2020-12-31 | 131 | 79d | 0d |  |
| 140 | 2.4.12 | Prepare 1st Draft CSER | 30d | 2020-11-20 | 2020-12-31 | 133 | 79d | 0d |  |
| 141 | 2.4.13 | Prepare 1st Draft NSR | 30d | 2020-11-20 | 2020-12-31 | 132 | 79d | 0d |  |
| 142 | 2.4.14 | Prepare Draft Section 4(f) | 30d | 2020-11-20 | 2020-12-31 | 137 | 79d | 0d |  |
| 143 | 2.4.15 | District Review 1st Draft Environmental Reports (NRE, CSER, CRAS, Noise, Section 4(f)) | 20d | 2021-01-01 | 2021-01-28 | 138, 139, 140, 141, 142 | 79d | 0d |  |
| 144 | 2.4.16 | Comment Resolution & Update Draft Environmental Reports | 15d | 2021-01-29 | 2021-02-18 | 143 | 79d | 0d |  |
| 145 | 2.4.17 | OEM Review NRE | 25d | 2021-02-19 | 2021-03-25 | 144 | 79d | 0d |  |
| 146 | 2.4.18 | Finalize CRAS | 10d | 2021-02-19 | 2021-03-04 | 144 | 126d | 0d | 333 |
| 147 | 2.4.19 | Finalize NRE Report | 10d | 2021-03-26 | 2021-04-08 | 145 | 79d | 61d | 761 |
| 148 | 2.4.20 | Section 106 Effects Complete | 1d | 2021-03-05 | 2021-03-05 | 146 | 126d |  | 762 |
| 149 | 2.4.21 | Submit NRE to USFWS, NMFS, USACE, and FWS | 1d | 2021-07-05 | 2021-07-05 | 120, 147 | 18d | 0d |  |
| 150 | 2.4.22 | Informal USFWS Consultation Complete | 22d | 2021-07-06 | 2021-08-04 | 149 | 18d |  | 752 |
| 151 | 2.4.23 | Informal NMFS Consultation Complete | 22d | 2021-07-06 | 2021-08-04 | 149 | 18d |  | 763 |
| 152 | 2.4.24 | Prepare Conceptual Stage Relocation Plan | 20d | 2021-07-05 | 2021-07-30 | 120 | 21d |  |  |

| ID | WBS | Task | Type | Duration | Start | Finish | Predecessors | Total slack | Free slack | PSM Codes |
| --- | --- | --- | --- | --- | --- | --- | --- | --- | --- | --- |
| 153 | 2.5 | **FINAL ENGINEERING & EIS DOCUMENTATION** |  | 979d | 2019-07-03 | 2023-04-03 |  | 0d |  |  |
| 154 | 2.5.1 | Prepare Draft EIS for Public Availability |  | 50d | 2021-08-31 | 2021-11-08 | 18, 120, 124, 148, 150, 151, 152, 167, 35 | 0d |  |  |
| 155 | 2.5.2 | District QC Draft Environmental Document |  | 20d | 2021-11-09 | 2021-12-06 | 154 | 0d |  | 713 |
| 156 | 2.5.3 | DEIS to OEM Initial Review |  | 23d | 2021-12-07 | 2022-01-06 | 155 | 0d |  | 714 |
| 157 | 2.5.4 | DEIS to Cooperating Agency Initial Review |  | 23d | 2021-12-07 | 2022-01-06 | 155 | 0d |  | 720 |
| 158 | 2.5.5 | District Prepares Responses |  | 12d | 2022-01-07 | 2022-01-24 | 156, 157 | 0d |  | 773 |
| 159 | 2.5.6 | OEM/District Comments Resolution |  | 24d | 2022-01-25 | 2022-02-25 | 158 | 0d |  | 774 |
| 160 | 2.5.7 | DEIS OEM Approval Final Review |  | 32d | 2022-02-28 | 2022-04-12 | 159 | 0d |  | 715 |
| 161 | 2.5.8 | Prepare Final EIS and ROD |  | 30d | 2022-08-04 | 2022-09-14 | 64 | 0d |  |  |
| 162 | 2.5.9 | Finalize Engineering & Environmental Reports |  | 30d | 2022-08-04 | 2022-09-14 | 64 | 0d |  |  |
| 163 | 2.5.10 | Finalize Section 4(f) |  | 5d | 2022-08-04 | 2022-08-10 | 64 | 25d |  | 751 |
| 164 | 2.5.11 | Finalize PD&E NSR |  | 5d | 2022-08-04 | 2022-08-10 | 64 | 25d |  | 335 |
| 165 | 2.5.12 | Finalize PER |  | 30d | 2022-08-04 | 2022-09-14 | 64 | 0d |  | 760 |
| 166 | 2.5.13 | District QC Final EIS |  | 20d | 2022-09-15 | 2022-10-12 | 161, 162, 163, 164, 165 | 0d |  |  |
| 167 | 2.5.14 | Planning Consistency Complete |  | 1d | 2019-07-03 | 2019-07-03 | 35 | 563d |  | 710 |
| 168 | 2.5.15 | FEIS/ROD OEM Initial Review |  | 23d | 2022-10-13 | 2022-11-14 | 166 | 0d |  | 727 |
| 169 | 2.5.16 | FEIS/ROD to Cooperating Agency Initial Review |  | 23d | 2022-10-13 | 2022-11-14 | 166 | 0d |  | 735 |
| 170 | 2.5.17 | District Prepares Responses |  | 12d | 2022-11-15 | 2022-11-30 | 168, 169 | 0d |  | 773 |
| 171 | 2.5.18 | OEM/District Comments Resolution |  | 24d | 2022-12-01 | 2023-01-03 | 170 | 0d |  | 774 |
| 172 | 2.5.19 | FEIS/ROD OEM Approval Final Review, and Legal Sufficiency Review |  | 54d | 2023-01-04 | 2023-03-20 | 171 | 0d |  | 728 |
| 173 | 2.5.20 | Location Design Concept Acceptance |  | 1d | 2023-03-21 | 2023-03-21 | 172 | 2d | 0d | 263 |
| 174 | 2.5.21 | Upload Final EIS to ETDM for Electronic Distribution |  | 1d | 2023-03-21 | 2023-03-21 | 172 | 2d | 0d |  |
| 175 | 2.5.22 | Distribute Final EIS (Hard Copies) |  | 1d | 2023-03-21 | 2023-03-21 | 172 | 2d | 0d |  |
| 176 | 2.5.23 | District Place Notice of Availability in Local Newspaper(s) |  | 1d | 2023-03-21 | 2023-03-21 | 172 | 2d | 0d |  |
| 177 | 2.5.24 | Location Design Concept Acceptance Public Notice | milestone | 1d | 2023-03-22 | 2023-03-22 | 172, 173, 174, 175, 176 | 2d | 0d | 736 |
| 178 | 2.5.25 | District Files Final EIS with EPA through e-NEPA |  | 1d | 2023-03-31 | 2023-03-31 | 172FS+8d | 0d |  |  |
| 179 | 2.5.26 | Interchange Access Request Approval |  | 5d | 2023-03-23 | 2023-03-29 | 97, 177 | 2d |  | 765 |
| 180 | 2.5.27 | Pass the Torch Meeting |  | 1d | 2023-04-03 | 2023-04-03 | 177, 179, 178 | 0d |  |  |
