# PLANNING AND PD&E (SEIR)

Schedule from MS Project, 2017-09-21 to 2021-01-29.

## Calendars

- Standard: Mon-Fri 08:00-12:00, 13:00-17:00; Sat-Sun off.

## Schedule

| ID | WBS | Task | Type | Duration | Start | Finish | Predecessors | Total slack | Constraint | PSM Codes |
| --- | --- | --- | --- | --- | --- | --- | --- | --- | --- | --- |
| 1 | 1 | **PLANNING & PRE-PD&E ACTIVITIES** |  | 409d | 2017-09-21 | 2019-04-16 |  | 0d |  |  |
| 2 | 1.1 | SWAT Planning Meeting (May take place 6 months to 5 years before SWAT Kickoff Meeting) | milestone | 1d | 2017-09-21 | 2017-09-21 |  | 0d | finish no earlier than 2017-09-21 | 746 |
| 3 | 1.2 | SWAT Strategy Meeting (6 months after the SWAT Planning Meeting when the Tentative Work Program has been submitted) |  | 1d | 2018-03-26 | 2018-03-26 | 2FS+131d | 0d |  | 770 |
| 4 | 1.3 | Assign PD&E Project Manager |  | 1d | 2018-03-27 | 2018-03-27 | 3 | 19d |  | 704 |
| 5 | 1.4 | SWAT Kickoff Meeting |  | 1d | 2018-09-20 | 2018-09-20 | 12FS+10d | 0d |  | 747 |
| 6 | 1.5 | **ETDM PROGRAMMING SCREEN** |  | 97d | 2018-04-24 | 2018-09-05 |  | 0d |  |  |
| 7 | 1.5.1 | ETDM Programming Screen PED |  | 20d | 2018-04-24 | 2018-05-21 | 3FS+20d, 4 | 0d |  |  |
| 8 | 1.5.2 | ETDM Programming Screen Purpose and Need |  | 20d | 2018-04-24 | 2018-05-21 | 3FS+20d | 0d |  |  |
| 9 | 1.5.3 | ETDM/ETAT Programming Screen Start |  | 32d | 2018-05-22 | 2018-07-04 | 7, 8, 4 | 0d |  | 700 |
| 10 | 1.5.4 | Advance Notification |  | 32d | 2018-05-22 | 2018-07-04 | 4, 7, 8 | 0d |  | 224 |
| 11 | 1.5.5 | ETDM Programming Screen Responses |  | 44d | 2018-07-05 | 2018-09-04 | 9, 10 | 0d |  |  |
| 12 | 1.5.6 | ETDM Programming Final Summary Report Published |  | 1d | 2018-09-05 | 2018-09-05 | 11 | 0d |  | 702 |
| 13 | 1.6 | **DEVELOP SCOPE AND SCHEDULE** |  | 20d | 2018-09-21 | 2018-10-18 |  | 0d |  |  |
| 14 | 1.6.1 | Initial PD&E Scope (Stage 1) and Schedule Complete |  | 20d | 2018-09-21 | 2018-10-18 | 12, 5 | 0d |  | 164 |
| 15 | 1.7 | **PROCUREMENT** |  | 128d | 2018-10-19 | 2019-04-16 |  | 0d |  |  |
| 16 | 1.7.1 | PD&E Advertisement |  | 1d | 2018-10-19 | 2018-10-19 | 14 | 0d |  | 705 |
| 17 | 1.7.2 | Procurement |  | 120d | 2018-10-22 | 2019-04-05 | 16 | 0d |  |  |
| 18 | 1.7.3 | Final PD&E Scope (Stage 3) |  | 5d | 2019-04-08 | 2019-04-12 | 17 | 0d |  | 164 |
| 19 | 1.7.4 | PD&E Contract Executed |  | 1d | 2019-04-15 | 2019-04-15 | 18 | 0d |  | 239 |
| 20 | 1.7.5 | Notice to Proceed | milestone | 1d | 2019-04-16 | 2019-04-16 | 18, 19 | 0d | start no earlier than 2016-04-01 | 234 |
| 21 | 2 | **PD&E STUDY** |  | 468d | 2019-04-17 | 2021-01-29 |  | 0d |  |  |
| 22 | 2.1 | **PROJECT MANAGEMENT** |  | 7d | 2019-04-17 | 2019-04-25 |  | 0d |  |  |
| 23 | 2.1.1 | SEIR Start |  | 1d | 2019-04-17 | 2019-04-17 | 20 | 0d |  | 709 |
| 24 | 2.1.2 | Prepare Project Management Plan |  | 5d | 2019-04-18 | 2019-04-24 | 23 | 0d |  |  |
| 25 | 2.1.3 | Prepare QC Plan |  | 5d | 2019-04-18 | 2019-04-24 | 23 | 0d |  |  |
| 26 | 2.1.4 | Project Kickoff Meeting with FDOT |  | 1d | 2019-04-25 | 2019-04-25 | 24, 25 | 0d |  |  |

| ID | WBS | Task | Type | Duration | Start | Finish | Predecessors | Total slack | Free slack | PSM Codes |
| --- | --- | --- | --- | --- | --- | --- | --- | --- | --- | --- |
| 27 | 2.2 | **PUBLIC INVOLVEMENT** |  | 423d | 2019-04-18 | 2020-11-30 |  | 0d |  |  |
| 28 | 2.2.1 | Prepare Public Involvement Plan |  | 20d | 2019-04-18 | 2019-05-15 | 23 | 53d | 31d | 748 |
| 29 | 2.2.2 | Public Involvement Data Collection |  | 45d | 2019-04-26 | 2019-06-27 | 26 | 22d | 0d |  |
| 30 | 2.2.3 | **Prepare for Public Kickoff Meeting** |  | 47d | 2019-06-28 | 2019-09-02 |  | 22d |  | 365 |
| 31 | 2.2.3.1 | Site Review |  | 1d | 2019-06-28 | 2019-06-28 | 28, 29 | 22d | 0d |  |
| 32 | 2.2.3.2 | Newsletter |  | 20d | 2019-07-01 | 2019-07-26 | 31 | 22d | 0d |  |
| 33 | 2.2.3.3 | Prepare Newspaper/ FAR/ FDOT Website Notice |  | 20d | 2019-07-01 | 2019-07-26 | 31 | 22d | 0d |  |
| 34 | 2.2.3.4 | Prepare Elected/Appointed/Property Owner Letters |  | 20d | 2019-07-01 | 2019-07-26 | 31 | 22d | 0d |  |
| 35 | 2.2.3.5 | Presentation/Display Material Review |  | 15d | 2019-07-29 | 2019-08-16 | 34, 32, 33 | 22d | 0d |  |
| 36 | 2.2.3.6 | Public Kickoff Meeting | milestone | 1d | 2019-08-19 | 2019-08-19 | 62, 35 | 22d | 0d | 292 |
| 37 | 2.2.3.7 | Public Comment Period |  | 10d | 2019-08-20 | 2019-09-02 | 36 | 22d | 0d |  |
| 38 | 2.2.4 | **Prepare for Public Information Meeting** |  | 76d | 2019-11-18 | 2020-03-02 |  | 0d |  | 365 |
| 39 | 2.2.4.1 | Site Review |  | 1d | 2019-11-18 | 2019-11-18 | 98FS-60d, 37 | 29d | 0d |  |
| 40 | 2.2.4.2 | Newsletter |  | 20d | 2019-11-19 | 2019-12-16 | 39 | 29d | 0d |  |
| 41 | 2.2.4.3 | Prepare Newspaper/ FAR/ FDOT Website Notice |  | 20d | 2019-11-19 | 2019-12-16 | 39 | 29d | 0d |  |
| 42 | 2.2.4.4 | Prepare Elected/Appointed/Property Owner Letters |  | 20d | 2019-11-19 | 2019-12-16 | 39 | 29d | 0d |  |
| 43 | 2.2.4.5 | Presentation/Display Material Review |  | 15d | 2019-12-17 | 2020-01-06 | 39, 40, 41, 42 | 29d |  |  |
| 44 | 2.2.4.6 | Public Information Meeting | milestone | 1d | 2020-02-17 | 2020-02-17 | 98FS+5d, 43 | 0d |  | 292 |
| 45 | 2.2.4.7 | Public Comment Period |  | 10d | 2020-02-18 | 2020-03-02 | 44 | 0d |  |  |
| 46 | 2.2.5 | **Prepare for Public Hearing** |  | 81d | 2020-08-10 | 2020-11-30 |  | 0d |  | 366 |
| 47 | 2.2.5.1 | Site Review |  | 20d | 2020-08-10 | 2020-09-04 | 45, 133FS-60d | 0d |  |  |
| 48 | 2.2.5.2 | Newsletter |  | 20d | 2020-09-07 | 2020-10-02 | 47 | 0d |  |  |
| 49 | 2.2.5.3 | Prepare Newspaper/ FAR/ FDOT Website Notice |  | 20d | 2020-09-07 | 2020-10-02 | 47 | 0d |  |  |
| 50 | 2.2.5.4 | Prepare Elected/Appointed/Property Owner Letters |  | 20d | 2020-09-07 | 2020-10-02 | 47 | 0d |  |  |
| 51 | 2.2.5.5 | Presentation/Display Material Review |  | 15d | 2020-10-05 | 2020-10-23 | 47, 48, 49, 50 | 0d |  |  |
| 52 | 2.2.5.6 | Document Available for Public Review |  | 15d | 2020-10-26 | 2020-11-13 | 51, 133FS-5d, 82, 109 | 0d |  |  |
| 53 | 2.2.5.7 | Public Hearing | milestone | 1d | 2020-11-16 | 2020-11-16 | 52, 51 | 0d |  | 262 |
| 54 | 2.2.5.8 | Public Comment Period |  | 10d | 2020-11-17 | 2020-11-30 | 53 | 0d |  |  |

| ID | WBS | Task | Duration | Start | Finish | Predecessors | Total slack | Free slack | PSM Codes |
| --- | --- | --- | --- | --- | --- | --- | --- | --- | --- |
| 55 | 2.3 | **ENGINEERING ANALYSIS** | 389d | 2019-04-18 | 2020-10-13 |  | 6d |  |  |
| 56 | 2.3.1 | **Data Collection** | 30d | 2019-04-26 | 2019-06-06 |  | 73d |  |  |
| 57 | 2.3.1.1 | Roadway Data Collection | 30d | 2019-04-26 | 2019-06-06 | 26 | 84d | 0d |  |
| 58 | 2.3.1.2 | Drainage Data Collection | 30d | 2019-04-26 | 2019-06-06 | 26 | 84d | 0d |  |
| 59 | 2.3.1.3 | Bridge Data Collection | 30d | 2019-04-26 | 2019-06-06 | 26 | 84d | 0d |  |
| 60 | 2.3.1.4 | Geotechnical Data Collection | 30d | 2019-04-26 | 2019-06-06 | 26 | 84d | 0d |  |
| 61 | 2.3.1.5 | Topographic Survey and ROW Mapping | 30d | 2019-04-26 | 2019-06-06 | 26 | 84d | 0d |  |
| 62 | 2.3.1.6 | Prepare Base Map | 30d | 2019-04-26 | 2019-06-06 | 26 | 73d | 0d |  |
| 63 | 2.3.2 | **Traffic Analysis** | 114d | 2019-04-26 | 2019-10-02 |  | 0d |  |  |
| 64 | 2.3.2.1 | Traffic Methodology Meeting | 1d | 2019-04-26 | 2019-04-26 | 26 | 0d |  |  |
| 65 | 2.3.2.2 | Traffic Methodology Memorandum | 10d | 2019-04-29 | 2019-05-10 | 64 | 0d |  |  |
| 66 | 2.3.2.3 | Forecasting and Analysis | 23d | 2019-05-13 | 2019-06-12 | 65 | 0d |  |  |
| 67 | 2.3.2.4 | Prepare Traffic Projections | 20d | 2019-06-13 | 2019-07-10 | 66 | 0d |  |  |
| 68 | 2.3.2.5 | Prepare Capacity Analysis | 20d | 2019-07-11 | 2019-08-07 | 67 | 0d |  |  |
| 69 | 2.3.2.6 | Draft Traffic Analysis Report | 20d | 2019-08-08 | 2019-09-04 | 68 | 0d |  |  |
| 70 | 2.3.2.7 | District Review - Draft Traffic Analysis Report | 15d | 2019-09-05 | 2019-09-25 | 69 | 0d |  |  |
| 71 | 2.3.2.8 | Final Traffic Analysis Report | 5d | 2019-09-26 | 2019-10-02 | 70 | 0d |  | 757 |
| 72 | 2.3.3 | **Interchange Access Request** | 199d | 2019-04-18 | 2020-01-21 |  | 198d |  |  |
| 73 | 2.3.3.1 | Initiate IAR | 1d | 2019-04-18 | 2019-04-18 | 23 | 270d | 0d |  |
| 74 | 2.3.3.2 | Prepare MLOU | 10d | 2019-04-19 | 2019-05-02 | 73 | 270d | 0d |  |
| 75 | 2.3.3.3 | DIRC/SPO Review of MLOU | 15d | 2019-05-03 | 2019-05-23 | 74 | 270d | 72d |  |
| 76 | 2.3.3.4 | Develop Alternatives | 30d | 2019-09-03 | 2019-10-14 | 37, 75 | 198d | 0d |  |
| 77 | 2.3.3.5 | Perform Operational Analysis | 20d | 2019-10-15 | 2019-11-11 | 76 | 198d | 0d |  |
| 78 | 2.3.3.6 | Prepare Preliminary IAR | 20d | 2019-11-12 | 2019-12-09 | 77 | 198d | 0d |  |
| 79 | 2.3.3.7 | DIRC/SPO Review of Preliminary IAR | 10d | 2019-12-10 | 2019-12-23 | 78 | 198d | 0d |  |
| 80 | 2.3.3.8 | Comment Resolution & Prepare Final IAR | 10d | 2019-12-24 | 2020-01-06 | 79 | 198d | 0d |  |
| 81 | 2.3.3.9 | DIRC/SPO Review of Final IAR | 10d | 2020-01-07 | 2020-01-20 | 80 | 198d | 0d |  |
| 82 | 2.3.3.10 | Safety, Operations and Engineering and IAR Approval | 1d | 2020-01-21 | 2020-01-21 | 81 | 198d |  | 765 |

| ID | WBS | Task | Duration | Start | Finish | Predecessors | Total slack | Free slack | PSM Codes |
| --- | --- | --- | --- | --- | --- | --- | --- | --- | --- |
| 83 | 2.3.4 | **Alternative Analysis** | 353d | 2019-06-07 | 2020-10-13 |  | 8d |  |  |
| 84 | 2.3.4.1 | Roadway Analysis | 30d | 2019-09-03 | 2019-10-14 | 37 | 52d |  |  |
| 85 | 2.3.4.2 | Structure Analysis | 30d | 2019-06-07 | 2019-07-18 | 57, 58, 59, 60, 61 | 114d |  |  |
| 86 | 2.3.4.3 | Typical Sections Analysis | 20d | 2019-09-03 | 2019-09-30 | 57, 58, 59, 60, 61, 62, 37 | 62d |  |  |
| 87 | 2.3.4.4 | Complete Streets/Multi Modal Analysis | 30d | 2019-06-07 | 2019-07-18 | 57, 58, 59, 60, 61, 62 | 114d |  |  |
| 88 | 2.3.4.5 | Transit Analysis | 30d | 2019-10-03 | 2019-11-13 | 57, 58, 59, 60, 61, 71, 111 | 30d |  |  |
| 89 | 2.3.4.6 | Concept Development | 30d | 2019-10-03 | 2019-11-13 | 57, 58, 59, 60, 61, 62, 71, 37 | 0d |  |  |
| 90 | 2.3.4.7 | Access Management Analysis | 30d | 2019-10-03 | 2019-11-13 | 71 | 30d |  |  |
| 91 | 2.3.4.8 | Drainage Analysis | 30d | 2019-11-14 | 2019-12-25 | 89 | 0d |  |  |
| 92 | 2.3.4.9 | Utility Coordination & Analysis | 30d | 2019-11-14 | 2019-12-25 | 89 | 0d |  |  |
| 93 | 2.3.4.10 | Transportation Management Plan | 20d | 2019-11-14 | 2019-12-11 | 89 | 10d |  |  |
| 94 | 2.3.4.11 | Railroad Coordination | 30d | 2019-11-14 | 2019-12-25 | 89 | 0d |  |  |
| 95 | 2.3.4.12 | Evaluation Matrix (1st Draft) | 5d | 2019-12-26 | 2020-01-01 | 86, 87, 91, 92, 94, 90, 89, 111, 93, 84, 85, 88, 112 | 0d |  |  |
| 96 | 2.3.4.13 | Construction Cost Estimates (LRE) | 10d | 2020-01-02 | 2020-01-15 | 95 | 12d |  |  |
| 97 | 2.3.4.14 | Right-of-Way Analysis | 10d | 2020-01-02 | 2020-01-15 | 95 | 12d |  |  |
| 98 | 2.3.4.15 | Evaluation Matrix (2nd Draft) | 5d | 2020-02-03 | 2020-02-07 | 96, 97, 113, 114, 115, 116, 117, 118 | 0d |  |  |
| 99 | 2.3.4.16 | Risk Management | 25d | 2020-02-10 | 2020-03-13 | 98 | 76d |  |  |
| 100 | 2.3.4.17 | Refine Alternatives (based on public input) | 20d | 2020-03-03 | 2020-03-30 | 45 | 0d |  |  |
| 101 | 2.3.4.18 | Prepare 1st Draft Engineering Reports (Drainage, Utility, Roadway Plans, ITS, Lighting, Pavement, Geotech, PER) | 30d | 2020-03-31 | 2020-05-11 | 45, 71, 100 | 0d |  |  |
| 102 | 2.3.4.19 | District Review - 1st Draft Engineering Reports | 20d | 2020-05-12 | 2020-06-08 | 101 | 0d |  |  |
| 103 | 2.3.4.20 | Comment Resolution & Update 1st Draft Engineering Reports | 15d | 2020-06-09 | 2020-06-29 | 102 | 0d |  |  |
| 104 | 2.3.4.21 | Value Engineering Study | 5d | 2020-06-30 | 2020-07-06 | 103, 99 | 0d |  |  |
| 105 | 2.3.4.22 | Value Engineering Review | 10d | 2020-08-04 | 2020-08-17 | 104FS+20d | 0d |  | 339 |
| 106 | 2.3.4.23 | Typical Section Selection | 1d | 2020-08-18 | 2020-08-18 | 105 | 28d | 20d | 759 |
| 107 | 2.3.4.24 | Prepare Design Variations and Exceptions | 20d | 2020-08-18 | 2020-09-14 | 105 | 8d | 0d |  |
| 108 | 2.3.4.25 | Alternatives Evaluation Complete | 1d | 2020-09-15 | 2020-09-15 | 107 | 8d | 0d | 712 |
| 109 | 2.3.4.26 | District Review - 2nd Draft Engineering Reports (Drainage, Utility, Roadway Plans, ITS, Lighting, Pavement, Geotech, PER) | 20d | 2020-09-16 | 2020-10-13 | 106, 108 | 8d |  |  |

| ID | WBS | Task | Type | Duration | Start | Finish | Predecessors | Total slack | Free slack | PSM Codes |
| --- | --- | --- | --- | --- | --- | --- | --- | --- | --- | --- |
| 110 | 2.4 | **ENVIRONMENTAL ANALYSIS** |  | 362d | 2019-04-26 | 2020-09-14 |  | 0d |  |  |
| 111 | 2.4.1 | Environmental GIS Data Collection |  | 15d | 2019-04-26 | 2019-05-16 | 26 | 129d | 0d |  |
| 112 | 2.4.2 | Environmental GIS Desktop Analysis |  | 30d | 2019-05-17 | 2019-06-27 | 111 | 129d |  |  |
| 113 | 2.4.3 | Data Collection & CRAS |  | 22d | 2020-01-02 | 2020-01-31 | 95 | 0d |  |  |
| 114 | 2.4.4 | Data Collection & Noise Analysis |  | 22d | 2020-01-02 | 2020-01-31 | 95, 71 | 0d |  |  |
| 115 | 2.4.5 | Data Collection & Contamination Screen Evaluation |  | 22d | 2020-01-02 | 2020-01-31 | 95 | 0d |  |  |
| 116 | 2.4.6 | Wetland Delineation and Evaluation |  | 22d | 2020-01-02 | 2020-01-31 | 95 | 0d |  |  |
| 117 | 2.4.7 | Data Collection & Wildlife Survey |  | 22d | 2020-01-02 | 2020-01-31 | 95 | 0d |  |  |
| 118 | 2.4.8 | Essential Fish Habitat Evaluation |  | 22d | 2020-01-02 | 2020-01-31 | 95 | 0d |  |  |
| 119 | 2.4.9 | Prepare 1st Draft NRE Report |  | 22d | 2020-02-03 | 2020-03-03 | 116, 117, 118 | 68d | 0d |  |
| 120 | 2.4.10 | Prepare 1st Draft CRAS |  | 22d | 2020-02-03 | 2020-03-03 | 113 | 68d | 0d |  |
| 121 | 2.4.11 | Prepare 1st Draft CSER |  | 22d | 2020-02-03 | 2020-03-03 | 115 | 68d | 0d |  |
| 122 | 2.4.12 | Prepare 1st Draft NSR |  | 22d | 2020-02-03 | 2020-03-03 | 114 | 68d | 0d |  |
| 123 | 2.4.13 | District Review 1st Draft Environmental Reports (NRE, CSER, CRAS, Noise) |  | 20d | 2020-03-04 | 2020-03-31 | 119, 120, 121, 122 | 68d | 0d |  |
| 124 | 2.4.14 | Comment Resolution & Update Draft Environmental Reports |  | 15d | 2020-04-01 | 2020-04-21 | 123 | 68d | 0d |  |
| 125 | 2.4.15 | OEM Review NRE |  | 25d | 2020-04-22 | 2020-05-26 | 124 | 68d | 0d |  |
| 126 | 2.4.16 | Finalize CRAS |  | 10d | 2020-04-22 | 2020-05-05 | 124 | 93d | 0d | 333 |
| 127 | 2.4.17 | Finalize NRE Report |  | 10d | 2020-05-27 | 2020-06-09 | 125 | 68d | 49d | 761 |
| 128 | 2.4.18 | Section 106 Effects Complete |  | 1d | 2020-05-06 | 2020-05-06 | 126 | 93d |  | 762 |
| 129 | 2.4.19 | Submit NRE to USFWS, NMFS, USACE, and FWS |  | 1d | 2020-08-18 | 2020-08-18 | 105, 127 | 19d |  |  |
| 130 | 2.4.20 | Prepare Conceptual Stage Relocation Plan |  | 20d | 2020-08-18 | 2020-09-14 | 105 | 0d |  |  |
| 131 | 2.5 | **FINAL ENGINEERING & SEIR DOCUMENTATION** |  | 99d | 2020-09-15 | 2021-01-29 |  | 0d |  |  |
| 132 | 2.5.1 | Prepare Draft SEIR for Public Availability |  | 20d | 2020-09-15 | 2020-10-12 | 105, 12, 128, 130, 129 | 0d |  |  |
| 133 | 2.5.2 | District QC Draft Environmental Document |  | 14d | 2020-10-13 | 2020-10-30 | 132 | 0d |  | 713 |
| 134 | 2.5.3 | Finalize Engineering & Environmental Reports |  | 10d | 2020-12-01 | 2020-12-14 | 54 | 10d |  |  |
| 135 | 2.5.4 | Finalize PD&E NSR |  | 5d | 2020-12-01 | 2020-12-07 | 54 | 0d |  | 335 |
| 136 | 2.5.5 | Finalize PER |  | 10d | 2020-12-01 | 2020-12-14 | 54 | 10d |  | 760 |
| 137 | 2.5.6 | Prepare FINAL SEIR |  | 15d | 2020-12-08 | 2020-12-28 | 54, 135 | 0d |  |  |
| 138 | 2.5.7 | Submit FINAL SEIR to District Secretary |  | 10d | 2020-12-29 | 2021-01-11 | 137, 134, 136 | 0d |  |  |
| 139 | 2.5.8 | SEIR Approved | milestone | 1d | 2021-01-14 | 2021-01-14 | 138FS+2d | 0d |  | 734 |
| 140 | 2.5.9 | Location Design Concept Acceptance |  | 1d | 2021-01-15 | 2021-01-15 | 139 | 8d | 0d | 263 |
| 141 | 2.5.10 | Location Design Concept Acceptance Public Notice |  | 1d | 2021-01-18 | 2021-01-18 | 140 | 8d |  | 736 |
| 142 | 2.5.11 | Pass the Torch Meeting |  | 1d | 2021-01-29 | 2021-01-29 | 139FS+10d, 141 | 0d |  |  |
